# CP9-2

Schedule from MS Project, 2005-01-01 to 2005-02-13.
Virginia Tech

## Calendars

- Standard: Mon-Sun 08:00-12:00, 13:00-17:00.

## Schedule

| ID | Task | Duration | Start | Finish | Predecessors | Total slack | Free slack |
| --- | --- | --- | --- | --- | --- | --- | --- |
| 1 | Excavation, pour footers | 4d | 2005-01-01 | 2005-01-04 |  | 0d |  |
| 2 | Lay foundation | 3d | 2005-01-05 | 2005-01-07 | 1 | 0d |  |
| 3 | Frame and roof | 4d | 2005-01-08 | 2005-01-11 | 2 | 0d |  |
| 4 | Lay drain tiles | 2d | 2005-01-08 | 2005-01-09 | 2 | 26d | 20d |
| 5 | Sewer (floor) drains | 2d | 2005-01-08 | 2005-01-09 | 2 | 0d |  |
| 6 | Install insulation | 4d | 2005-01-12 | 2005-01-15 | 3 | 0d |  |
| 7 | Pour basement floors | 3d | 2005-01-10 | 2005-01-12 | 5 | 0d |  |
| 8 | Rough plumbing, pipes | 4d | 2005-01-10 | 2005-01-13 | 5 | 4d |  |
| 9 | Install windows | 3d | 2005-01-16 | 2005-01-18 | 6 | 6d | 0d |
| 10 | Rough electrical wiring | 2d | 2005-01-16 | 2005-01-17 | 6 | 0d |  |
| 11 | Install furnace, air conditioner | 5d | 2005-01-13 | 2005-01-17 | 3, 7 | 0d |  |
| 12 | Exterior brickwork | 6d | 2005-01-19 | 2005-01-24 | 9 | 6d | 0d |
| 13 | Install plasterboard, mud, plaster | 8d | 2005-01-18 | 2005-01-25 | 8, 10, 11 | 0d |  |
| 14 | Roof shingles, flashing | 3d | 2005-01-25 | 2005-01-27 | 12 | 6d | 0d |
| 15 | Attach gutter, downspouts | 2d | 2005-01-28 | 2005-01-29 | 14 | 6d | 0d |
| 16 | Grading | 3d | 2005-01-30 | 2005-02-01 | 4, 15 | 6d | 0d |
| 17 | Lay subflooring | 4d | 2005-01-26 | 2005-01-29 | 13 | 0d |  |
| 18 | Lay driveway, walks, landscape | 6d | 2005-02-02 | 2005-02-07 | 16 | 6d |  |
| 19 | Finish carpentry | 5d | 2005-01-30 | 2005-02-03 | 17 | 5d |  |
| 20 | Kitchen cabinetry, sink, and appliances | 4d | 2005-01-30 | 2005-02-02 | 17 | 0d |  |
| 21 | Bathroom cabinetry, fixtures | 3d | 2005-01-30 | 2005-02-01 | 17 | 1d |  |
| 22 | Painting (interior and exterior) | 6d | 2005-02-03 | 2005-02-08 | 20, 21 | 0d |  |
| 23 | Finish wood floors, lay carpet | 5d | 2005-02-09 | 2005-02-13 | 22, 19 | 0d |  |
| 24 | Final electrical, light fixtures | 3d | 2005-02-09 | 2005-02-11 | 22 | 2d |  |
