# HW8-24

Schedule from MS Project, 2005-04-01 to 2011-05-25.
Virginia Tech

## Calendars

- Standard: Mon-Fri 08:00-12:00, 13:00-17:00; Sat-Sun off.

## Schedule

| ID | Task | Duration | Start | Finish | Predecessors | Total slack | Free slack |
| --- | --- | --- | --- | --- | --- | --- | --- |
| 1 | General design | 11.17mo | 2005-04-01 | 2006-02-08 |  | 80d | 0d |
| 2 | Engine design | 34.83mo | 2005-04-01 | 2007-12-03 |  | 0d |  |
| 3 | Airframe design | 17.83mo | 2006-02-08 | 2007-06-21 | 1 | 80d | 0d |
| 4 | Avionics design | 9mo | 2006-02-08 | 2006-10-18 | 1 | 173.33d | 0d |
| 5 | Develop test engine | 9.83mo | 2007-12-03 | 2008-09-03 | 2 | 0d |  |
| 6 | Develop test airframe | 11.67mo | 2007-06-22 | 2008-05-14 | 3 | 80d |  |
| 7 | Develoop interim avionics | 15.83mo | 2006-10-18 | 2008-01-03 | 4 | 173.33d |  |
| 8 | Engine development | 26mo | 2007-12-03 | 2009-11-30 | 2 | 50d | 0d |
| 9 | Assemble test aircraft | 6.33mo | 2008-09-03 | 2009-02-26 | 5, 6, 7 | 0d |  |
| 10 | Test avionics | 10.17mo | 2006-10-18 | 2007-07-30 | 4 | 373.33d | 0d |
| 11 | Engine/airframe flight trials | 8.83mo | 2009-02-27 | 2009-11-02 | 9 | 0d |  |
| 12 | Avionics flight trials | 10.83mo | 2007-07-30 | 2008-05-28 | 10 | 373.33d |  |
| 13 | Engine production | 13.67mo | 2009-11-30 | 2010-12-16 | 8 | 50d |  |
| 14 | Airframe production | 15.33mo | 2009-11-02 | 2011-01-05 | 11 | 36.67d |  |
| 15 | Avionics production | 17.17mo | 2009-11-02 | 2011-02-24 | 11, 12 | 0d |  |
| 16 | Final assembly/finish | 3.17mo | 2011-02-25 | 2011-05-25 | 13, 14, 15 | 0d |  |
